# Projektavimo paslaugų grafikas

Schedule from MS Project, 2020-09-28 to 2021-12-15, costs in €.

## Calendars

- Standard: Mon-Fri 08:00-12:00, 13:00-17:00; Sat-Sun off. Exceptions (off unless hours are given): 2013-01-01 to 2030-01-01 (Naujieji metai, recurring), 2013-02-16 to 2030-02-16 (Valstybės atkurimo diena, recurring), 2013-03-11 to 2030-03-11 (Nepriklausomybes atkurimo diena, recurring), 2013-05-01 to 2030-05-01 (Tarptautine darbininku diena, recurring), 2013-06-24 to 2030-06-24 (Jonines (Rasos), recurring), 2013-07-06 to 2030-07-06 (Valstybes (Lietuvos karaliaus Mindaugo karunavimo) diena, recurring), 2013-08-15 to 2030-08-15 (Zoline, Sv. Mergeles Marijos dangun emimo svente, recurring), 2013-11-01 to 2030-11-01 (Visu sventuju diena, recurring), 2013-12-24 to 2030-12-24 (Sv. Kucios, recurring), 2013-12-25 to 2030-12-25 (Sv. Kaledos, recurring), 2013-12-26 to 2030-12-26 (Sv. Kaledos (antroji diena), recurring), 2019-06-20 to 2024-04-02 07:30-11:30, 12:15-16:30 (Darbo diena (I-IV) 07:30-16:30, recurring), 2019-06-21 to 2030-12-27 07:30-11:30, 12:15-15:15 (Darbo diena (V) 07:30-15:15, recurring), 2021-04-05 (Sv. Velykos (antroji diena)).

## Resources

| Resource | Rate |
| --- | --- |
| Rangovas |  |
| Litgrid AB |  |
| Ekspertizės rangovas |  |
| Infostatyba |  |
| PV |  |
| ESO |  |
| _ITTAD ITTC TIG vyresnysis inžinierius | 17.8 |
| _ITTAD ITTC DPG PVS administratorius | 17.8 |
| _ITTAD ITTC VSG DVS administratorius | 17.8 |
| _ITTAD ITTC DPG duomenų tinklo administratorius (KR) | 17.8 |
| _ITTAD ITTC DPG duomenų tinklo administratorius (IP) | 17.8 |
| _Rangovas |  |
| _ITTAD ITTC TIG grupės vadovas |  |
| _VAD FSS apsaugos sistemų specialistas |  |
| _ITTAD ITTC DPG grupės vadovas |  |
| _ITTAD ITTC TIG technologinio tinklo vyresnysis inžinierius |  |
| _ITTAD ITTC VSG grupės vadovas |  |
| _PTD DSAS darbuotojų saugos ir sveikatos vyresnysis inžinierius |  |
| _PTD DSAS aplinkosaugos vyresnysis inžinierius |  |
| _PTD RAAS skyriaus vadovas |  |
| _SVD SPS STRG RAA vadovaujantis inžinierius |  |
| _SVD SPS režimų planavimo grupės vadovas |  |
| _SVD SPS STRG inžinierius |  |
| _SVD SVC TVG ekspertas |  |
| _SVD SPS režimų planavimo grupės vadovaujantis inžinierius |  |
| _SVD SVC TVG analitikas |  |
| _PTD IPC Statybų priežiūros proceso vadovas |  |
| _ISPS kibernetinės saugos specialistas |  |
| _SD STS vadovaujantis inžinierius |  |
| _SVD ROPS RPPAG elektros apskaitų vadovaujantis inžinierius |  |
| _PTD TCHS linijų vyresnysis inžinierius |  |
| _PTD TCHS PPĮG pastočių vyresnysis inžinierius |  |
| _PTD TCHS RAA įrenginių grupės RAA vyresnysis inžinierius |  |
| _KS komunikacijos projektų vadovas |  |

## Schedule

| ID | WBS | Task | Type | Duration | Start | Finish | Predecessors | Baseline start | Baseline finish | Baseline duration | Total slack | Resources | Work | Cost |
| --- | --- | --- | --- | --- | --- | --- | --- | --- | --- | --- | --- | --- | --- | --- |
| 1 | 1 | S3 - Pasirašyta sutartis | milestone | 0d | 2020-09-28 | 2020-09-28 |  |  |  |  | 0d | Rangovas; Litgrid AB |  |  |
| 2 | 2 | Prašymas pateikti reikalingą dokumentaciją/informaciją projektavimo darbams |  | 5d | 2020-09-28 | 2020-10-05 | 1 |  |  |  | 0d | Rangovas | 40h |  |
| 3 | 3 | Pateikta reikalinga dokumentacija/informacija projektavimo darbams |  | 15d | 2020-10-05 | 2020-10-26 | 2 | 2019-12-18 | 2020-01-27 | 25d | 0d | Litgrid AB | 120h |  |
| 4 | 4 | **I ETAPAS. PROJEKTAVIMAS** |  | 309d | 2020-09-28 | 2021-12-15 |  | 2019-12-18 | 2020-08-18 | 166d | 0d |  | 8769.44h | 46,145.34 |
| 5 | 4.1 | **Projektiniai pasiūlymai** |  | 309d | 2020-09-28 | 2021-12-15 |  |  |  |  | 0d |  | 8769.44h | 46,145.34 |
| 6 | 4.1.1 | **Tiekėjo darbų atlikimo grafikas** |  | 56d | 2020-10-26 | 2021-01-14 |  |  |  |  | 0d |  | 0.13h |  |
| 7 | 4.1.1.1 | **Darbų atlikimo grafikas** |  | 56d | 2020-10-26 | 2021-01-14 |  |  |  |  | 0d |  | 0.13h |  |
| 8 | 4.1.1.1.1 | Parengti darbų atlikimo grafiką |  | 1d | 2020-10-26 | 2020-10-27 | 3 |  |  |  | 0d |  |  |  |
| 9 | 4.1.1.1.2 | Pateikti 1 peržiūrai darbų atlikimo grafiką |  | 21d | 2020-10-27 | 2020-11-24 | 8 |  |  |  | 0d | _Rangovas [0.1%] | 0.1h |  |
| 10 | 4.1.1.1.3 | Pateikti pastabas po 1 peržiūros |  | 10d | 2020-11-25 | 2020-12-08 | 9 |  |  |  | 0d |  |  |  |
| 11 | 4.1.1.1.4 | Pateikti 2 peržiūrai darbų atlikimo grafiką |  | 7d | 2020-12-09 | 2020-12-17 | 10 |  |  |  | 0d | _Rangovas [0.1%] | 0.03h |  |
| 12 | 4.1.1.1.5 | Pateikti pastabas po 2 peržiūros |  | 5d | 2020-12-17 | 2020-12-28 | 11 |  |  |  | 0d |  |  |  |
| 13 | 4.1.1.1.6 | Pateikti 3 peržiūrai darbų atlikimo grafiką |  | 7d | 2020-12-28 | 2021-01-07 | 12 |  |  |  | 0d |  |  |  |
| 14 | 4.1.1.1.7 | Pateikti pastabas po 3 peržiūros |  | 5d | 2021-01-07 | 2021-01-14 | 13 |  |  |  | 0d |  |  |  |
| 15 | 4.1.1.1.8 | Darbų atlikimo grafikas suderintas | milestone | 0d | 2021-01-14 | 2021-01-14 | 14 |  |  |  | 0d |  |  |  |
| 16 | 4.1.2 | **I ETAPAS. PROJEKTAVIMAS** |  | 186d | 2020-09-28 | 2021-06-22 |  |  |  |  | 76d |  | 6065.22h | 32,973.28 |
| 17 | 4.1.2.1 | Prašymas pateikti reikalingą dokumentaciją/informaciją techniniams darbams |  | 5d | 2021-01-14 | 2021-01-21 | 15 |  |  |  | 0d | _Rangovas [0.1%] | 0.02h |  |
| 18 | 4.1.2.2 | Pateikta reikalinga dokumentacija/informacija techniniams darbams |  | 10d | 2021-01-21 | 2021-02-04 | 17 |  |  |  | 0d | _ITTAD ITTC TIG grupės vadovas; _VAD FSS apsaugos sistemų specialistas; _ITTAD ITTC DPG duomenų tinklo administratorius (IP); _ITTAD ITTC DPG duomenų tinklo administratorius (KR); _ITTAD ITTC DPG PVS administratorius; _ITTAD ITTC DPG grupės vadovas; _ITTAD ITTC TIG technologinio tinklo vyresnysis inžinierius; _ITTAD ITTC TIG vyresnysis inžinierius; _ITTAD ITTC VSG DVS administratorius; _ITTAD ITTC VSG grupės vadovas; _PTD DSAS darbuotojų saugos ir sveikatos vyresnysis inžinierius; _PTD DSAS aplinkosaugos vyresnysis inžinierius; _PTD RAAS skyriaus vadovas; _SVD SPS STRG RAA vadovaujantis inžinierius; _SVD SPS režimų planavimo grupės vadovas; _SVD SPS STRG inžinierius; _SVD SVC TVG ekspertas; _SVD SPS režimų planavimo grupės vadovaujantis inžinierius; _SVD SVC TVG analitikas; _PTD IPC Statybų priežiūros proceso vadovas; _ISPS kibernetinės saugos specialistas; _SD STS vadovaujantis inžinierius; _SVD ROPS RPPAG elektros apskaitų vadovaujantis inžinierius | 751h | 5,838.4 |
| 19 | 4.1.2.3 | Specialiųjų prisijungimo sąlygų ir specialiųjų reikalavimų ir visų reikalingų suderinimų, leidimų gavimas |  | 5d | 2021-02-04 | 2021-02-11 | 18 |  |  |  | 213d |  |  |  |
| 20 | 4.1.2.4 | Sutikimų iš atsakingų institucijų ir asmenų gavimas |  | 5d | 2021-02-04 | 2021-02-11 | 18 |  |  |  | 213d |  |  |  |
| 21 | 4.1.2.5 | Konsultacijos rengimo metu |  | 25d | 2020-09-28 | 2020-11-02 | 1 |  |  |  | 284d | _ITTAD ITTC TIG grupės vadovas; _VAD FSS apsaugos sistemų specialistas; _ITTAD ITTC DPG duomenų tinklo administratorius (IP); _ITTAD ITTC DPG duomenų tinklo administratorius (KR); _ITTAD ITTC DPG PVS administratorius; _ITTAD ITTC DPG grupės vadovas; _ITTAD ITTC TIG technologinio tinklo vyresnysis inžinierius; _ITTAD ITTC TIG vyresnysis inžinierius; _ITTAD ITTC VSG DVS administratorius; _ITTAD ITTC VSG grupės vadovas; _PTD DSAS darbuotojų saugos ir sveikatos vyresnysis inžinierius; _PTD DSAS aplinkosaugos vyresnysis inžinierius; _PTD RAAS skyriaus vadovas; _PTD TCHS linijų vyresnysis inžinierius; _PTD TCHS PPĮG pastočių vyresnysis inžinierius; _PTD TCHS RAA įrenginių grupės RAA vyresnysis inžinierius; _SVD SPS STRG RAA vadovaujantis inžinierius; _SVD SPS režimų planavimo grupės vadovas; _SVD SPS STRG inžinierius; _SVD SVC TVG ekspertas; _PTD IPC Statybų priežiūros proceso vadovas; _SVD SPS režimų planavimo grupės vadovaujantis inžinierius; _SVD SVC TVG analitikas; _ISPS kibernetinės saugos specialistas; _SD STS vadovaujantis inžinierius; _SVD ROPS RPPAG elektros apskaitų vadovaujantis inžinierius | 1639h | 11,423.74 |
| 22 | 4.1.2.6 | Pateikti geologinių tyrinėjimų vietas susiderinimui |  | 5d | 2020-09-28 | 2020-10-05 | 1 |  |  |  | 304d | _Rangovas [0.1%] | 0.02h |  |
| 23 | 4.1.2.7 | Atlikti inžineriniai geodeziniai tyrinėjimai ir pateikta įregistravimo pažyma |  | 20d | 2021-02-04 | 2021-03-05 | 18 |  |  |  | 0d | _Rangovas [0.1%] | 0.1h |  |
| 24 | 4.1.2.8 | **Projektiniai pasiūlymai** |  | 75d | 2021-03-05 | 2021-06-22 |  |  |  |  | 0d |  | 3675.08h | 15,711.14 |
| 25 | 4.1.2.8.1 | Projektinių pasiūlymų projekto rengimas |  | 30d | 2021-03-05 | 2021-04-20 | 23 |  |  |  | 0d | _Rangovas [0.1%] | 0h |  |
| 26 | 4.1.2.8.2 | Pakoreguoti ir pateikti projektinių pasiūlymų projektą 1 peržiūrai | milestone | 0d | 2021-04-20 | 2021-04-20 | 25 |  |  |  | 0d |  |  |  |
| 27 | 4.1.2.8.3 | Pateikti pastabas po 1 projektinių pasiūlymų projekto peržiūros |  | 10d | 2021-04-20 | 2021-05-04 | 26 |  |  |  | 0d | _VAD FSS apsaugos sistemų specialistas; _ITTAD ITTC DPG duomenų tinklo administratorius (IP); _ITTAD ITTC DPG duomenų tinklo administratorius (KR); _ITTAD ITTC DPG PVS administratorius; _ITTAD ITTC DPG grupės vadovas; _ITTAD ITTC TIG technologinio tinklo vyresnysis inžinierius; _ITTAD ITTC TIG grupės vadovas; _ITTAD ITTC TIG vyresnysis inžinierius; _ITTAD ITTC VSG DVS administratorius; _ITTAD ITTC VSG grupės vadovas; _PTD DSAS darbuotojų saugos ir sveikatos vyresnysis inžinierius; _PTD DSAS aplinkosaugos vyresnysis inžinierius; _PTD RAAS skyriaus vadovas; _PTD TCHS linijų vyresnysis inžinierius; _PTD TCHS PPĮG pastočių vyresnysis inžinierius; _PTD TCHS RAA įrenginių grupės RAA vyresnysis inžinierius; _SVD SPS STRG RAA vadovaujantis inžinierius; _SVD SPS režimų planavimo grupės vadovas; _SVD SPS STRG inžinierius; _SVD SVC TVG ekspertas; _SVD SPS režimų planavimo grupės vadovaujantis inžinierius; _PTD IPC Statybų priežiūros proceso vadovas; _SVD SVC TVG analitikas; _ISPS kibernetinės saugos specialistas; _SD STS vadovaujantis inžinierius; _SVD ROPS RPPAG elektros apskaitų vadovaujantis inžinierius | 1161h | 5,718.73 |
| 28 | 4.1.2.8.4 | Pakoreguoti ir pateikti projektinių pasiūlymų projektą 2 peržiūrai |  | 10d | 2021-05-04 | 2021-05-18 | 27 |  |  |  | 0d | _Rangovas [0.1%] | 0.05h |  |
| 29 | 4.1.2.8.5 | Pateikti pastabas po 2 projektinių pasiūlymų projekto peržiūros |  | 10d | 2021-05-18 | 2021-06-01 | 28 |  |  |  | 0d | _VAD FSS apsaugos sistemų specialistas; _ITTAD ITTC DPG duomenų tinklo administratorius (IP); _ITTAD ITTC DPG duomenų tinklo administratorius (KR); _ITTAD ITTC DPG PVS administratorius; _ITTAD ITTC DPG grupės vadovas; _ITTAD ITTC TIG technologinio tinklo vyresnysis inžinierius; _ITTAD ITTC TIG grupės vadovas; _ITTAD ITTC TIG vyresnysis inžinierius; _ITTAD ITTC VSG DVS administratorius; _ITTAD ITTC VSG grupės vadovas; _PTD DSAS darbuotojų saugos ir sveikatos vyresnysis inžinierius; _PTD DSAS aplinkosaugos vyresnysis inžinierius; _PTD RAAS skyriaus vadovas; _PTD TCHS linijų vyresnysis inžinierius; _PTD TCHS PPĮG pastočių vyresnysis inžinierius; _PTD TCHS RAA įrenginių grupės RAA vyresnysis inžinierius; _SVD SPS STRG RAA vadovaujantis inžinierius; _SVD SPS režimų planavimo grupės vadovas; _SVD SPS STRG inžinierius; _SVD SVC TVG ekspertas; _SVD SPS režimų planavimo grupės vadovaujantis inžinierius; _SVD SVC TVG analitikas; _ISPS kibernetinės saugos specialistas; _PTD IPC Statybų priežiūros proceso vadovas; _SD STS vadovaujantis inžinierius; _SVD ROPS RPPAG elektros apskaitų vadovaujantis inžinierius | 2080h | 7,120 |
| 30 | 4.1.2.8.6 | Pakoreguoti ir pateikti projektinių pasiūlymų projektą 3 peržiūrai |  | 5d | 2021-06-01 | 2021-06-08 | 29 |  |  |  | 0d | _Rangovas [0.1%] | 0.02h |  |
| 31 | 4.1.2.8.7 | Pateikti pastabas/suderinti po 3 projektinių pasiūlymų projekto |  | 10d | 2021-06-08 | 2021-06-22 | 30 |  |  |  | 0d | _VAD FSS apsaugos sistemų specialistas; _ITTAD ITTC DPG duomenų tinklo administratorius (IP); _ITTAD ITTC DPG duomenų tinklo administratorius (KR); _ITTAD ITTC DPG PVS administratorius; _ITTAD ITTC DPG grupės vadovas; _ITTAD ITTC TIG technologinio tinklo vyresnysis inžinierius; _ITTAD ITTC TIG grupės vadovas; _ITTAD ITTC TIG vyresnysis inžinierius; _ITTAD ITTC VSG DVS administratorius; _ITTAD ITTC VSG grupės vadovas; _PTD DSAS darbuotojų saugos ir sveikatos vyresnysis inžinierius; _PTD DSAS aplinkosaugos vyresnysis inžinierius; _PTD RAAS skyriaus vadovas; _PTD TCHS linijų vyresnysis inžinierius; _PTD TCHS PPĮG pastočių vyresnysis inžinierius; _PTD TCHS RAA įrenginių grupės RAA vyresnysis inžinierius; _SVD SPS STRG RAA vadovaujantis inžinierius; _SVD SPS režimų planavimo grupės vadovas; _SVD SPS STRG inžinierius; _SVD SVC TVG ekspertas; _SVD SPS režimų planavimo grupės vadovaujantis inžinierius; _PTD IPC Statybų priežiūros proceso vadovas; _SVD SVC TVG analitikas; _ISPS kibernetinės saugos specialistas; _SD STS vadovaujantis inžinierius; _SVD ROPS RPPAG elektros apskaitų vadovaujantis inžinierius | 434h | 2,872.42 |
| 32 | 4.1.2.8.8 | Projektiniai pasiūlymai suderinti | milestone | 0d | 2021-06-22 | 2021-06-22 | 31 |  |  |  | 0d |  |  |  |
| 33 | 4.1.2.8.9 | Projektiniai pasiūlymai patvirtinti | milestone | 0d | 2021-06-22 | 2021-06-22 | 32 |  |  |  | 0d |  |  |  |

Notes:
- 4: jeigu perkame iki rakto - paliekame. / Jeigu perkame atskirai - padaryti inactive ar i�trinti
- 21: Pagal poreikį konsultacijos daromos
- 33: kai taikoma

| ID | WBS | Task | Type | Duration | Start | Finish | Predecessors | Total slack | Resources | Work | Cost |
| --- | --- | --- | --- | --- | --- | --- | --- | --- | --- | --- | --- |
| 34 | 4.1.3 | **Statybos leidimas** |  | 133d | 2021-06-08 | 2021-12-15 |  | 0d |  | 2704.08h | 13,172.05 |
| 35 | 4.1.3.1 | Komunikacija (Projektinių sprendinių pristatymas visuomenei) |  | 3d | 2021-06-08 | 2021-06-11 | 36SS-10d | 130d | _KS komunikacijos projektų vadovas | 4h |  |
| 36 | 4.1.3.2 | Techninis projektas pateiktas į Infostatybą su visais reikiamais dokumentais |  | 1d | 2021-06-22 | 2021-06-23 | 32, 33 | 0d | _Rangovas [0.1%] | 0h |  |
| 37 | 4.1.3.3 | Patikrinta pateiktos dokumentacijos sudėtis |  | 3d | 2021-06-23 | 2021-06-29 | 36 | 0d | Infostatyba | 24h |  |
| 38 | 4.1.3.4 | Suinteresuotos organizacijos patikrino pateiktą dokumentaciją |  | 20d | 2021-06-29 | 2021-07-28 | 37 | 0d | Infostatyba | 160h |  |
| 39 | 4.1.3.5 | Išduotas statybos leidimas |  | 3d | 2021-07-28 | 2021-08-02 | 38 | 0d | Infostatyba | 24h |  |
| 40 | 4.1.3.6 | S4 - Statybos leidimas gautas | milestone | 0d | 2021-08-02 | 2021-08-02 | 39 | 0d |  |  |  |
| 41 | 4.1.3.7 | Komunikacija (SLD gavimas arba Statybos darbų pradžia) |  | 4d | 2021-08-02 | 2021-08-06 | 40SS | 92d | _KS komunikacijos projektų vadovas | 3h |  |
| 42 | 4.1.3.8 | **TDP (techninis darbo projektas) suderintas/patvirtintas (DAR BUS TIKSLINAMAS)** |  | 96d | 2021-08-02 | 2021-12-15 |  | 0d |  | 2489.08h | 13,172.05 |
| 43 | 4.1.3.8.1 | **Techninis darbo projektas** |  | 96d | 2021-08-02 | 2021-12-15 |  | 0d |  | 2489.08h | 13,172.05 |
| 44 | 4.1.3.8.1.1 | Techninio darbo projekto rengimas |  | 30d | 2021-08-02 | 2021-09-13 | 40 | 0d | _Rangovas [0.1%] | 0h |  |
| 45 | 4.1.3.8.1.2 | Pakoreguoti ir pateikti techninį darbo projektą 1 peržiūrai | milestone | 0d | 2021-09-13 | 2021-09-13 | 44 | 0d |  |  |  |
| 46 | 4.1.3.8.1.3 | Pateikti pastabas po 1 techninio darbo projekto peržiūros |  | 10d | 2021-09-13 | 2021-09-27 | 45 | 0d | _VAD FSS apsaugos sistemų specialistas; _ITTAD ITTC DPG duomenų tinklo administratorius (IP); _ITTAD ITTC DPG duomenų tinklo administratorius (KR); _ITTAD ITTC DPG PVS administratorius; _ITTAD ITTC DPG grupės vadovas; _ITTAD ITTC TIG technologinio tinklo vyresnysis inžinierius; _ITTAD ITTC TIG grupės vadovas; _ITTAD ITTC TIG vyresnysis inžinierius; _ITTAD ITTC VSG DVS administratorius; _ITTAD ITTC VSG grupės vadovas; _PTD DSAS darbuotojų saugos ir sveikatos vyresnysis inžinierius; _PTD DSAS aplinkosaugos vyresnysis inžinierius; _PTD RAAS skyriaus vadovas; _PTD TCHS linijų vyresnysis inžinierius; _PTD TCHS PPĮG pastočių vyresnysis inžinierius; _PTD TCHS RAA įrenginių grupės RAA vyresnysis inžinierius; _SVD SPS STRG RAA vadovaujantis inžinierius; _SVD SPS režimų planavimo grupės vadovas; _SVD SPS STRG inžinierius; _SVD SVC TVG ekspertas; _SVD SPS režimų planavimo grupės vadovaujantis inžinierius; _PTD IPC Statybų priežiūros proceso vadovas; _SVD SVC TVG analitikas; _ISPS kibernetinės saugos specialistas; _SD STS vadovaujantis inžinierius; _SVD ROPS RPPAG elektros apskaitų vadovaujantis inžinierius | 1161h | 5,718.73 |
| 47 | 4.1.3.8.1.4 | Pakoreguoti ir pateikti techninį darbo projektą 2 peržiūrai |  | 10d | 2021-09-27 | 2021-10-11 | 46 | 0d | _Rangovas [0.1%] | 0.05h |  |
| 48 | 4.1.3.8.1.5 | Pateikti pastabas po 2 techninio darbo projekto peržiūros |  | 10d | 2021-10-11 | 2021-10-25 | 47 | 0d | _VAD FSS apsaugos sistemų specialistas; _ITTAD ITTC DPG duomenų tinklo administratorius (IP); _ITTAD ITTC DPG duomenų tinklo administratorius (KR); _ITTAD ITTC DPG PVS administratorius; _ITTAD ITTC DPG grupės vadovas; _ITTAD ITTC TIG technologinio tinklo vyresnysis inžinierius; _ITTAD ITTC TIG grupės vadovas; _ITTAD ITTC TIG vyresnysis inžinierius; _ITTAD ITTC VSG DVS administratorius; _ITTAD ITTC VSG grupės vadovas; _PTD DSAS darbuotojų saugos ir sveikatos vyresnysis inžinierius; _PTD DSAS aplinkosaugos vyresnysis inžinierius; _PTD RAAS skyriaus vadovas; _PTD TCHS linijų vyresnysis inžinierius; _PTD TCHS PPĮG pastočių vyresnysis inžinierius; _PTD TCHS RAA įrenginių grupės RAA vyresnysis inžinierius; _SVD SPS STRG RAA vadovaujantis inžinierius; _SVD SPS režimų planavimo grupės vadovas; _SVD SPS STRG inžinierius; _SVD SVC TVG ekspertas; _SVD SPS režimų planavimo grupės vadovaujantis inžinierius; _SVD SVC TVG analitikas; _ISPS kibernetinės saugos specialistas; _PTD IPC Statybų priežiūros proceso vadovas; _SD STS vadovaujantis inžinierius; _SVD ROPS RPPAG elektros apskaitų vadovaujantis inžinierius | 726h | 4,580.91 |
| 49 | 4.1.3.8.1.6 | Pakoreguoti ir pateikti techninį darbo projektą 3 peržiūrai |  | 5d | 2021-10-25 | 2021-11-02 | 48 | 0d | _Rangovas [0.1%] | 0.02h |  |
| 50 | 4.1.3.8.1.7 | Pateikti pastabas/suderinti po 3 techninio darbo projekto peržiūros |  | 10d | 2021-11-02 | 2021-11-16 | 49 | 0d | _VAD FSS apsaugos sistemų specialistas; _ITTAD ITTC DPG duomenų tinklo administratorius (IP); _ITTAD ITTC DPG duomenų tinklo administratorius (KR); _ITTAD ITTC DPG PVS administratorius; _ITTAD ITTC DPG grupės vadovas; _ITTAD ITTC TIG technologinio tinklo vyresnysis inžinierius; _ITTAD ITTC TIG grupės vadovas; _ITTAD ITTC TIG vyresnysis inžinierius; _ITTAD ITTC VSG DVS administratorius; _ITTAD ITTC VSG grupės vadovas; _PTD DSAS darbuotojų saugos ir sveikatos vyresnysis inžinierius; _PTD DSAS aplinkosaugos vyresnysis inžinierius; _PTD RAAS skyriaus vadovas; _PTD TCHS linijų vyresnysis inžinierius; _PTD TCHS PPĮG pastočių vyresnysis inžinierius; _PTD TCHS RAA įrenginių grupės RAA vyresnysis inžinierius; _SVD SPS STRG RAA vadovaujantis inžinierius; _SVD SPS režimų planavimo grupės vadovas; _SVD SPS STRG inžinierius; _SVD SVC TVG ekspertas; _SVD SPS režimų planavimo grupės vadovaujantis inžinierius; _PTD IPC Statybų priežiūros proceso vadovas; _SVD SVC TVG analitikas; _ISPS kibernetinės saugos specialistas; _SD STS vadovaujantis inžinierius; _SVD ROPS RPPAG elektros apskaitų vadovaujantis inžinierius | 434h | 2,872.42 |
| 51 | 4.1.3.8.1.8 | Techninis darbo projektas suderintas ir patvirtintas | milestone | 0d | 2021-11-16 | 2021-11-16 | 50 | 0d |  |  |  |
| 52 | 4.1.3.8.1.9 | **Techninio darbo projekto bendroji ekspertizė** |  | 21d | 2021-11-16 | 2021-12-15 |  | 0d |  | 168h |  |
| 53 | 4.1.3.8.1.9.1 | Techninio darbo projekto bendroji ekspertizė |  | 20d | 2021-11-16 | 2021-12-14 | 51 | 0d | Ekspertizės rangovas | 160h |  |
| 54 | 4.1.3.8.1.9.2 | Pateikta ekspertizės teigiama išvada projektui |  | 1d | 2021-12-14 | 2021-12-15 | 53 | 0d | Ekspertizės rangovas | 8h |  |
| 55 | 4.1.3.8.1.9.3 | S5 - Gautas teigiamas TDP ekspertizės aktas | milestone | 0d | 2021-12-15 | 2021-12-15 | 54 | 0d |  |  |  |
| 56 | 4.1.3.8.1.9.4 | Pateiktas nurodymas apie techninio darbo projekto bendrųjų statinio rodiklių patvirtinimą | milestone | 0d | 2021-12-15 | 2021-12-15 | 55 | 0d |  |  |  |

Notes:
- 35: Jei reikalingas projektinių sprendinių pristatymas visuomenei (vie�inimo procedūros) pagal teisės aktus. Tikslas - vie�inti Litgrid tinklapyje apie projektinių sprendinių vie�inimo procedūr¹.
